# Proyecto1A

Schedule from MS Project, 2020-12-07 to 2021-04-07, costs in ₡.

## Calendars

- Estándar: Mon-Fri 09:00-13:00, 15:00-19:00; Sat-Sun off.

## Resources

| Resource | Group | Rate |
| --- | --- | --- |
| Arquitecto | contratado | 85 |
| Ayudante del DP | personal oficina | 40 |
| Carpintero | mantenimiento | 55 |
| Responsable de finanzas | directiva | 60 |
| Técnico informático 1 | técnicos | 45 |
| Técnico informático 2 | técnicos | 35 |
| Electricista | mantenimiento | 30 |
| Empresa constructora | contratado | 80 |
| Jefe de oficina | directiva | 100 |
| Director Proyecto | directiva | 100 |
| Pintor | mantenimiento | 35 |
| Presidente | directiva | 60 |
| Agente inmobiliario | contratado | 75 |
| Vicepresidente | directiva | 100 |

## Schedule

| ID | WBS | Task | Type | Duration | Start | Finish | Predecessors | Total slack | Resources | Work | Cost |
| --- | --- | --- | --- | --- | --- | --- | --- | --- | --- | --- | --- |
| 1 | 1 | **Planning** |  | 39d | 2020-12-07 | 2021-01-28 |  | 0d |  | 760h | 67,840 |
| 2 | 1.1 | write proposal |  | 3d | 2020-12-07 | 2020-12-09 |  | 0d | Director Proyecto; Jefe de oficina | 48h | 4,800 |
| 3 | 1.2 | hire architect |  | 2d | 2020-12-10 | 2020-12-11 | 2 | 0d | Jefe de oficina; Vicepresidente | 32h | 3,200 |
| 4 | 1.3 | Locate new location |  | 1w | 2020-12-14 | 2020-12-18 | 3 | 0d | Arquitecto; Jefe de oficina; Agente inmobiliario | 120h | 10,400 |
| 5 | 1.4 | submit proposal |  | 2d | 2020-12-21 | 2020-12-22 | 4 | 0d | Director Proyecto; Arquitecto; Presidente; Vicepresidente | 64h | 5,520 |
| 6 | 1.5 | Directive approval | milestone | 0d | 2020-12-22 | 2020-12-22 | 5 | 0d | Director Proyecto; Presidente; Vicepresidente |  |  |
| 7 | 1.6 | Negotiate new rent |  | 4d | 2020-12-23 | 2020-12-28 | 6 | 0d | Vicepresidente; Responsable de finanzas; Agente inmobiliario | 96h | 7,520 |
| 8 | 1.7 | finish drawings |  | 1w | 2020-12-25 | 2020-12-31 | 7FS-2d | 0d | Arquitecto [200%] | 80h | 6,800 |
| 9 | 1.8 | Select subcontractors |  | 2w | 2021-01-01 | 2021-01-14 | 8 | 0d | Arquitecto; Director Proyecto; Jefe de oficina | 224h | 21,200 |
| 10 | 1.9 | Hire moving company |  | 4d | 2021-01-11 | 2021-01-14 | 9FF | 0d | Director Proyecto [75%] | 16h | 1,600 |
| 11 | 1.10 | send drawings |  | 2w | 2021-01-15 | 2021-01-28 | 10 | 0d | Arquitecto | 80h | 6,800 |
| 12 | 1.11 | permissions received | milestone | 0d | 2021-01-28 | 2021-01-28 | 11 | 0d | Ayudante del DP |  |  |
| 13 | 2 | **Remodeling** |  | 39d | 2021-01-29 | 2021-03-24 |  | 0d |  | 412h | 20,540 |
| 14 | 2.1 | Demolition of existing space |  | 3d | 2021-01-29 | 2021-02-02 | 1 | 0d | Empresa constructora | 24h | 1,920 |
| 15 | 2.2 | raise partitions |  | 3d | 2021-02-03 | 2021-02-05 | 14 | 0d | Empresa constructora [150%] | 36h | 2,880 |
| 16 | 2.3 | Electrical installation |  | 6d | 2021-02-08 | 2021-02-15 | 15 | 0d | Electricista | 48h | 1,440 |
| 17 | 2.4 | Installation of voice and data lines |  | 3d | 2021-02-17 | 2021-02-19 | 16FS+1d | 0d | Electricista | 24h | 720 |
| 18 | 2.5 | finish walls |  | 1w | 2021-02-22 | 2021-02-26 | 17 | 0d | Pintor; Empresa constructora | 80h | 4,600 |
| 19 | 2.6 | Install doors and windows |  | 3d | 2021-02-25 | 2021-03-01 | 18FS-2d | 0d | Carpintero | 24h | 1,320 |
| 20 | 2.7 | Paint |  | 4d | 2021-03-02 | 2021-03-05 | 19 | 0d | Pintor | 32h | 1,120 |
| 21 | 2.8 | place offices |  | 3d | 2021-03-08 | 2021-03-10 | 20 | 0d | Carpintero | 24h | 1,320 |
| 22 | 2.9 | place server room |  | 3d | 2021-03-08 | 2021-03-10 | 21SS | 0d | Técnico informático 1 | 24h | 1,080 |
| 23 | 2.10 | last repairs |  | 1w | 2021-03-11 | 2021-03-17 | 21, 22 | 0d | Carpintero [50%]; Electricista [50%] | 40h | 1,700 |
| 24 | 2.11 | test systems |  | 2d | 2021-03-18 | 2021-03-19 | 23 | 1d | Electricista | 16h | 480 |
| 25 | 2.12 | finish check |  | 3d | 2021-03-18 | 2021-03-22 | 23, 24FF | 0d | Carpintero | 24h | 1,320 |
| 26 | 2.13 | Final cleaning |  | 2d | 2021-03-23 | 2021-03-24 | 25 | 0d | Ayudante del DP | 16h | 640 |
| 27 | 2.14 | finished remodel | milestone | 0d | 2021-03-24 | 2021-03-24 | 26 | 0d | Director Proyecto; Empresa constructora |  |  |

| ID | WBS | Task | Type | Duration | Start | Finish | Predecessors | Total slack | Free slack | Resources | Work | Cost |
| --- | --- | --- | --- | --- | --- | --- | --- | --- | --- | --- | --- | --- |
| 28 | 3 | **Transfer** |  | 9.5d | 2021-03-25 | 2021-04-07 | 13 | 0d |  |  | 176h | 8,440 |
| 29 | 3.1 | **Offices** |  | 6.5d | 2021-03-25 | 2021-04-02 |  | 0d |  |  | 108h | 5,420 |
| 30 | 3.1.1 | Disconnect computers/equipment |  | 2d | 2021-03-25 | 2021-03-26 |  | 0d |  | Técnico informático 1 | 16h | 720 |
| 31 | 3.1.2 | dismantle furniture |  | 2d | 2021-03-26 | 2021-03-29 | 30FS-1d | 3d | 0d | Ayudante del DP; Carpintero | 32h | 1,520 |
| 32 | 3.1.3 | Moving furniture/equipment/crates |  | 4h | 2021-03-30 | 2021-03-30 | 31 | 3d | 0d | Ayudante del DP; Carpintero; Empresa constructora | 12h | 700 |
| 33 | 3.1.4 | Assemble furniture |  | 2d | 2021-03-30 | 2021-04-01 | 32 | 3d | 0d | Ayudante del DP; Empresa constructora | 32h | 1,920 |
| 34 | 3.1.5 | Connect computers/equipment |  | 2d | 2021-03-31 | 2021-04-02 | 33FS-1d | 3d | 0d | Técnico informático 2 | 16h | 560 |
| 35 | 3.1.6 | finished offices | milestone | 0d | 2021-04-02 | 2021-04-02 | 34 | 3d |  | Director Proyecto; Empresa constructora |  |  |
| 36 | 3.2 | **server room** |  | 7.5d | 2021-03-29 | 2021-04-07 |  | 0d |  |  | 68h | 3,020 |
| 37 | 3.2.1 | Back up the server |  | 2d | 2021-03-29 | 2021-03-30 | 30 | 0d |  | Técnico informático 1 | 16h | 720 |
| 38 | 3.2.2 | disconnect server |  | 2d | 2021-03-31 | 2021-04-01 | 37 | 0d |  | Técnico informático 1 | 16h | 720 |
| 39 | 3.2.3 | move server |  | 4h | 2021-04-02 | 2021-04-02 | 38 | 0d |  | Técnico informático 2 | 4h | 140 |
| 40 | 3.2.4 | connect server |  | 2d | 2021-04-02 | 2021-04-06 | 39 | 0d |  | Técnico informático 1 | 16h | 720 |
| 41 | 3.2.5 | test server |  | 1d | 2021-04-06 | 2021-04-07 | 40 | 0d |  | Técnico informático 1 [200%] | 16h | 720 |
| 42 | 3.2.6 | finished server room | milestone | 0d | 2021-04-07 | 2021-04-07 | 41 | 0d |  | Director Proyecto; Técnico informático 1; Técnico informático 2 |  |  |
| 43 | 4 | transfer finished | milestone | 0d | 2021-04-07 | 2021-04-07 | 28, 35 | 0d |  | Director Proyecto; Empresa constructora |  |  |
